# Cronograma Plan Implementación

Schedule from MS Project, 2026-01-12 to 2027-07-02, costs in $.

## Calendars

- Estándar: Mon-Fri 09:00-13:00, 15:00-19:00; Sat-Sun off.

## Resources

| Resource | Rate |
| --- | --- |
| Consultor DS | 120000 |
| Capacitador tipo 1 | 100000 |
| Auditor D | 110000 |
| Analista | 120000 |
| Tecnico TI | 90000 |
| Capacitador tipo 2 | 100000 |
| Tecnico VT | 90000 |
| Consultor VT | 120000 |
| Auditor VT | 110000 |
| Consultor DC | 120000 |
| Analista DP | 120000 |
| Capacitador tipo 3 | 100000 |
| Analista CESAC | 120000 |
| Tecnico CESAC | 90000 |
| Consultor GC | 120000 |

## Schedule

| ID | WBS | Task | Duration | Start | Finish | Predecessors | Total slack | Free slack | Resources | Work | Cost |
| --- | --- | --- | --- | --- | --- | --- | --- | --- | --- | --- | --- |
| 1 | 1 | **Plan de Implementación - Modelo de Gestión Tecnológica - Proceso Mantenimiento ARC** | 385d | 2026-01-12 | 2027-07-02 |  |  |  |  | 3000h | 304,400,000 |
| 2 | 1.1 | **Fortalecimiento de la cultura organizacional** | 55d | 2026-01-12 | 2026-03-27 |  |  |  |  | 360h | 39,200,000 |
| 3 | 1.1.1 | Diagnóstico y Sensibilización | 15d | 2026-01-12 | 2026-01-30 |  | 330d | 0d | Consultor DS | 120h | 14,400,000 |
| 4 | 1.1.2 | Capacitación Grupal | 20d | 2026-02-02 | 2026-02-27 | 3 | 330d | 0d | Capacitador tipo 1 | 160h | 16,000,000 |
| 5 | 1.1.3 | Incentivos y Reconocimiento | 10d | 2026-03-02 | 2026-03-13 | 4 | 55d | 0d |  |  |  |
| 6 | 1.1.4 | Monitoreo y Ajustes | 10d | 2026-03-16 | 2026-03-27 | 5 | 330d |  | Auditor D | 80h | 8,800,000 |
| 7 | 1.2 | **Modernización de la gestión del conocimiento** | 70d | 2026-01-12 | 2026-04-17 |  |  |  |  | 560h | 54,000,000 |
| 8 | 1.2.1 | Evaluación de Necesidades | 10d | 2026-01-12 | 2026-01-23 |  | 315d | 0d | Consultor GC | 80h | 9,600,000 |
| 9 | 1.2.2 | Desarrollo de la Plataforma Digital | 45d | 2026-01-26 | 2026-03-27 | 8 | 315d | 0d | Tecnico TI | 360h | 32,400,000 |
| 10 | 1.2.3 | Capacitación y Lanzamiento | 15d | 2026-03-30 | 2026-04-17 | 9 | 315d |  | Capacitador tipo 2 | 120h | 12,000,000 |
| 11 | 1.3 | **Institucionalización de la vigilancia tecnológica** | 80d | 2026-01-12 | 2026-05-01 |  |  |  |  | 640h | 67,200,000 |
| 12 | 1.3.1 | Creación de la División de Vigilancia | 30d | 2026-01-12 | 2026-02-20 |  | 305d | 0d | Auditor VT | 240h | 26,400,000 |
| 13 | 1.3.2 | Desarrollo de Herramientas de Monitoreo | 30d | 2026-02-23 | 2026-04-03 | 12 | 305d | 0d | Tecnico VT | 240h | 21,600,000 |
| 14 | 1.3.3 | Priorización de Tecnologías | 10d | 2026-04-06 | 2026-04-17 | 13 | 305d | 0d | Consultor VT | 80h | 9,600,000 |
| 15 | 1.3.4 | Evaluación de Impacto | 10d | 2026-04-20 | 2026-05-01 | 14 | 305d |  | Analista | 80h | 9,600,000 |
| 16 | 1.4 | **Profesionalización del talento humano** | 70d | 2026-01-12 | 2026-04-17 |  |  |  |  | 560h | 60,000,000 |
| 17 | 1.4.1 | Diagnóstico de Competencias | 10d | 2026-01-12 | 2026-01-23 |  | 315d | 0d | Consultor DC | 80h | 9,600,000 |
| 18 | 1.4.2 | Diseño de Programas | 15d | 2026-01-26 | 2026-02-13 | 17 | 315d | 0d | Analista DP | 120h | 14,400,000 |
| 19 | 1.4.3 | Implementación de Capacitaciones | 30d | 2026-02-16 | 2026-03-27 | 18 | 315d | 0d | Capacitador tipo 3 | 240h | 24,000,000 |
| 20 | 1.4.4 | Certificación y Evaluación | 15d | 2026-03-30 | 2026-04-17 | 19 | 315d |  | Capacitador tipo 3 | 120h | 12,000,000 |
| 21 | 1.5 | **Implementación del Centro de Supervisión y Análisis de Sistemas de la Armada de Colombia (CESAC)** | 110d | 2026-01-12 | 2026-06-12 |  |  |  |  | 880h | 84,000,000 |
| 22 | 1.5.1 | Estudio de Factibilidad | 20d | 2026-01-12 | 2026-02-06 |  | 275d | 0d | Analista CESAC | 160h | 19,200,000 |
| 23 | 1.5.2 | Diseño del Sistema | 25d | 2026-02-09 | 2026-03-13 | 22 | 275d | 0d | Tecnico CESAC | 200h | 18,000,000 |
| 24 | 1.5.3 | Pruebas Piloto | 25d | 2026-03-16 | 2026-04-17 | 23 | 275d | 0d | Tecnico CESAC | 200h | 18,000,000 |
| 25 | 1.5.4 | Despliegue | 40d | 2026-04-20 | 2026-06-12 | 24 | 275d |  | Tecnico CESAC | 320h | 28,800,000 |
